# Fedora 10
#
# Copyright 2008-2011 John Poelstra <poelstra@fedoraproject.org>
#
# Permission is hereby granted, free of charge, to any person
# obtaining a copy of this software and associated documentation files
# (the "Software"), to deal in the Software without restriction,
# including without limitation the rights to use, copy, modify, merge,
# publish, distribute, sublicense, and/or sell copies of the Software,
# and to permit persons to whom the Software is furnished to do so,
# subject to the following conditions:
#
# The above copyright notice and this permission notice shall be
# included in all copies or substantial portions of the Software.
#
# THE SOFTWARE IS PROVIDED "AS IS", WITHOUT WARRANTY OF ANY KIND,
# EXPRESS OR IMPLIED, INCLUDING BUT NOT LIMITED TO THE WARRANTIES OF
# MERCHANTABILITY, FITNESS FOR A PARTICULAR PURPOSE AND
# NONINFRINGEMENT.  IN NO EVENT SHALL THE AUTHORS OR COPYRIGHT HOLDERS
# BE LIABLE FOR ANY CLAIM, DAMAGES OR OTHER LIABILITY, WHETHER IN AN
# ACTION OF CONTRACT, TORT OR OTHERWISE, ARISING FROM, OUT OF OR IN
# CONNECTION WITH THE SOFTWARE OR THE USE OR OTHER DEALINGS IN THE
# SOFTWARE.
#

macro major         [10]
macro content       [f]
macro content_title [Fedora]
macro start_date    [2008-05-14]
macro end_date      [2010-01-31]
macro id            [$Id: f-10.tjp,v 1.36 2008/11/13 22:17:20 poelstra Exp $]
macro state         [$State: Exp $]
macro prior_project [f9]

project ${content}${major} "${content_title}" "${major}" ${start_date} - ${end_date} {
  timeformat "%Y-%b-%d"

  # Based on Eastern time zone in USA
  timezone "America/New_York"

  scenario plan "Original Plan" {
    scenario actual "Actual"
  }

  # Limit working days
  workinghours sat,sun off
}

include "reports.tji"
include "vacations.tji"

# key things to remember about Fedora schedules
# 1) they are time driven unless specified differently during planning
# 2) Freezes and releases always happen on Tuesdays
# 3) Composes always start on Thursdays
# 4) Beta snapshots happen on Thursday or Fridays and are best effort--nothing depends or waits on them

# Miscellaneous:
# 1) most tasks are scheduled with 'length' and 'effort' instead of duration
#   this lets TJ schedule tasks on "work days" only

# TODO: when building F11
# 1)Fix static dates
# 2) Consider reworking some task to be "precedes" and not "depends"
# 3) MOVE maintenance phases tasks related to F8 to planning phase for F11
# 4) normalize task_ids particularly in docs and translation sections to be descriptive and consistent
# 5) Normalize usage of "milestone" and "flags report_milestone" to report "milestones"
# 6) Gather important "web sites" task and integrate into schedule
# 7) remove "duration" usage as much as possible and replace with "length"


task ${content}${major} "${content_title} ${major}" {

  start ${start_date}
  task PlanningPhase "Planning Phase" {
    task features "Open Feature Submission" {
      plan: duration 97d
      flags quality, docs, art, releng, pm
    }

    task trackers "Create Tracker Bugs" {
      length 0.5d
      flags bugtriage, pm
      note "See details at https://fedoraproject.org/wiki/BugZappers/HouseKeeping/FirstDayDevel"
    }

    # In the future this task should line up with release engineering
    # obtaining an approved name for the release
    task art_round1 "Art Theme Round One" {
      length 60d
      flags art
    }

    task fudcon "Fudcon Fedora 10" {
      start 2008-06-19
      end 2008-06-21
      flags art, report_milestone, pm
    }

    # Required for product pages
    task export_freeze "Requirements Freeze" {
      depends !features
      milestone
      flags hidden
    }
  }

  task DevelopmentPhase "Development Phase" {
    start ${start_date}

    task beats "Wiki Release Note Beats" {
      flags docs
      # use duration instead of resource allocation
      # beause resource usage is casual and it messes up
      # overlapping alpha release notes prep resource allocation
      duration 99d
    }

    task develop "Packaging and Development" {
      length 70d
      flags devel
    }
  }

  task TestingPhase "Testing Phase" {
    task alpha "Alpha Release" {

      task freeze "Alpha Freeze" {
        start 2008-07-22
        milestone
        flags report_milestone, releng, docs, art, pm, translation
      }

      task art_concept "Three Conceptual Themes Sketched" {
        depends !!!PlanningPhase.art_round1
        flags art
      }

      task candidate "Create Alpha Candidate" {
        depends !freeze
        length 7d
        flags releng
      }

      task meeting "Alpha Release Meeting" {
        depends !freeze {gaplength 7d}
        milestone
        flags releng, pm, quality, docs, art, report_milestone
      }

      task stage "Compose Stage Sync" {
        depends !candidate
        length 4d
        flags releng
      }

      task prep_notes "Prepare Alpha Release Notes" {
        depends !freeze {gaplength 9d}
        length 1d
        flags docs, quality
      }

      task drop "Alpha Public Availability" {
        milestone
        depends !stage
        flags releng, docs, quality, report_milestone, pm, translation
      }

      task post_notes "Post Final Alpha Release Notes" {
        milestone
        depends !prep_notes
        flags docs
      }

      task test "Alpha Testing" {
        depends !stage
        plan: length 10d
        actual: length 26d
        flags quality
      }

      # begin of alpha testing
      task art_round2 "Art Theme Round Two"{
        depends !art_concept
        flags art
        task walpaper "Theme Walpaper Draft" { length 17d }
        task vertical "Virtically Long Supporting Artwork" {length 17d }
        task horizontal "Horizontally Long Supporting Artwork" { length 17d }
        task square "Square Supporting Artwork" { length 17d }
      }

      # 11 days before feature freeze
      # go through these for F11 to determine which ones will really be worked on
      task art_round3 "Art Theme Round Three"{
        depends !art_round2
        flags art
        task full_splash "Fullscreen splash for syslinux" { length 15d }
        task square_splash "Square splash for anaconda and firstboot" { length 15d }
        task anaconda "Anaconda horizontal header" { length 15d }
        task firstboot "Firstboot vertical header" { length 15d }
        task fullscreen_grub "Fullscreen grub splash" { length 15d }
        task bootup "bootup/loading graphics (plymouth?)" { length 15d }
        task kdm "kdm login screen theme" { length 15d }
        task gnome_splash "gnome splash screen" { length 15d }
        task kde "kde splash screen" { length 15d }
        task gnome_screensave "gnome screensaver lock dialog" { length 15d }
      }

      # must have this ready at beta or feature freeze
      # commenting out as this was not planned right to work from the beginning for F10
      /*
      task beta_pkg "Package Artwork for Beta"{
      depends !art_round3
      flags art, devel
      length 1d
      }*/

      # using 'precedes' and 'depends' in the same schedule is not a good idea
      # but nothing depends on this task
      task feature_remind "Send Feature Owner Freeze Reminder" {
        precedes !testmile {gaplength 5d}
        length 0.5d
        flags pm
        note "Remind feature owners to update their wiki pages for Feature Freeze"
      }

      task testmile "End of Alpha" {
        milestone
        depends !test
        flags quality, report_milestone, pm
      }
    } # end of alpha

    task beta "Beta Release" {
      depends !alpha.test

      task freeze "Beta Freeze" {
        milestone
        flags releng, report_milestone
      }

      # for future schedules consider staggering feature freeze from beta freeze
      # by one week so that the regular freeze goes smoother
      task feature_freeze "Feature Freeze" {
        milestone
        flags releng, report_milestone, art, quality, pm
        depends !freeze
      }

      # for F11 double-check this date with translation team
      task string "Software String Freeze" {
        depends !freeze
        milestone
        flags report_milestone, docs, translation, pm
      }

      task translate_software "Translate Period For Software (POT to PO)" {
        depends !string
        length 28d
        flags translation, pm
      }

      task docs_reminder "Nagmail to developers/beat writers" {
        depends !freeze
        flags docs
      }

      task meeting "Beta Release Meeting" {
        depends !freeze {gaplength 4d}
        milestone
        flags releng, pm, quality, docs, art, report_milestone, translation
      }

      task candidate "Create Beta Candidate" {
        depends !freeze
        plan: length 06d
        actual: length 04d
        flags releng
      }

      task prep_notes "Comb Beats and Feature Pages" {
        depends !freeze {gaplength 5d}
        plan: length 3.5d
        actual: length 7.5d
        flags docs, quality
      }

      task stage "Compose Stage Sync" {
        depends !candidate
        plan: length 3d
        actual: length 9d
        flags releng
      }

      task post_notes "Post Beta Release Notes One-Page" {
        milestone
        depends !prep_notes
        flags docs
      }

      # needs to be ready the day before beta public availability
      task banner "Banner Creation" {
        depends !freeze
        plan: length 9d
        actual: length 14d
        flags art
      }

      task drop "Beta Public Availability" {
        milestone
        flags releng, docs, quality, report_milestone, art, pm
        depends !stage
      }

      # start working on during beta to have at release of Preview Release
      # make sure linked to in release announcement
      task counter "Count Down Graphic" {
        depends !drop
        length 10d
        flags art
      }

      # Required for product pages
      task public_beta "Public Beta" {
        milestone
        depends !drop
        flags hidden
      }

      task branch "Allow Pre-branch F10" {
        milestone
        flags report_milestone, releng
        depends !drop
      }

      task test "Beta Testing" {
        depends !stage
        length 20d
        flags quality
      }

      # While there are dependencies between subsequent snapshots
      # this was just done to get them scheduled easily.
      # Each snapshot is "best effort" so if it doesn't go out
      # it does not hold up or affect subsequent tasks
      task snapshots "Snapshot Releases" {
        depends !!beta.drop {gapduration 8d}  # start approx one week after beta release
        flags releng # sets flag for entire sub-section

        task snap1 "Snapshot 1" {
          task stage "Compose Stage Sync" {
            length 2d
          }

          task drop "Public Availability" {
            depends !stage
          }
        }

        task snap2 "Snapshot 2" {
          depends !snap1 {gapduration 5d}
          task stage "Compose Stage Sync" {
            length 2d
          }

          task drop "Public Availability" {
            milestone
            flags releng
            depends !stage
          }
        }

        task snap3 "Snapshot 3" {
          depends !snap2 {gapduration 5d}
          task stage "Compose Stage Sync" {
            length 2d
          }

          task drop "Public Availability" {
            depends !stage
          }
        }
      }

      task wiki_freeze "Beta Freeze on Wiki for Preview Release" {
        depends !drop {gaplength 6d} # start this task 6 days after Beta starts
        flags docs
      }

      task wiki_prep "Prepare Wiki Beats for Port to Preview Release DocBook XML" {
        depends !wiki_freeze
        length 1d
        flags docs
      }

      task wiki_import "Import wiki content to fedorahosted.org/release-notes" {
        depends !wiki_prep
        length 0.5d
        flags docs
      }

      # FIXME: this task is late... record actual and resulting impact
      task create_pot "Generate POT files for all fedora-release-notes.rpm content" {
        depends !wiki_import
        length 0.5d
        flags docs
        note "F-R-N.rpm refers to the fedora-release-notes.rpm which contains several documentaiton files"
      }

      # this freeze is needed so that translation can start with frozen content
      task document_freeze "fedora-release-notes.rpm String Freeze" {
        depends !create_pot
        flags docs, report_milestone
        note "Documentation includes: release-notes, install-guide, readme, readme-burning-isos, about-fedora, readme-live-image"
      }

      task pot_trans "Translate Release Notes (POT to PO)" {
        depends !create_pot
        plan: length 7.5d
        actual: length 2d
        flags translation
      }

      task documentation_trans "Translate Documentation (POT to PO)" {
        depends !document_freeze
        length 7d
        flags translation
      }

      task trans_docs_deadline "Documentation Translation Deadline (PO Files complete)" {
        depends !documentation_trans
        milestone
        flags translation, report_milestone
      }

      # should be one week before "Final Development Freeze"
      task trans_deadline "Software Translation Deadline (PO Files complete)" {
        depends !translate_software
        milestone
        flags translation, report_milestone
      }

      task trans_rebuild "Rebuild all translated packages" {
        depends !trans_deadline
        length 5d
        flags translation
      }
      task feature_remind "Send Feature Owner 100% Reminder" {
        precedes !testmile {gaplength 5d}
        length 0.1h
        flags pm
        note "Remind feature owners that all feature pages need to be at 100% at 'Final Freeze'"
      }

      # FIXME: static date--add logic to dynamically select date
      task ig_string_freeze "Install Guide String Freeze" {
        start 2008-10-27
        milestone
        flags docs
      }

      task testmile "End of Beta" {
        milestone
        depends !test
        flags quality, report_milestone, pm
      }
    }

    task pr "Preview Release" {

      # 1 week before the Preview Release availability
      task finalfreeze "Final Development Freeze" {
        depends !!beta.test
        milestone
        flags report_milestone, releng, docs, art, quality, pm, translation
      }

      task build_pr_relnotes "Build fedora-release-notes.rpm for Preview Release" {
        depends !finalfreeze {gaplength 1d}
        length 0.2d
        flags docs
      }

      # FIXME: static date--add logic to dynamically select date
      task validate_frn_xml "Validate Release Notes Preview XML for all languages" {
        start 2008-10-30
        length 2d
        flags docs
      }

      # FIXME: static date--add logic to dynamically select date
      task validate_ig_xml "Validate Install Guide Preview XML for all languages" {
        start 2008-10-31
        length 2d
        flags docs
      }

      # FIXME: static date--add logic to dynamically select date
      task draft_ig_preview "Publish Install Guide Preview to web (non-live)" {
        start 2008-11-03
        length 0.2d
        flags docs
      }

      # FIXME: static date--add logic to dynamically select date
      task pub_ig_preview "Publish Install Guide Preview LIVE on web" {
        start 2008-11-04
        length 0.2d
        flags docs
      }

      # four weeks prior to GA prepare tickets for rawhide rebase & EOL warning
      task rebase_prep "Draft Bugzilla Ticket for Rawhide Rebase " {
        precedes !!!LaunchPhase.ga {gaplength 4w}
        length 0.2d
        flags pm, bugtriage
        note "https://fedoraproject.org/wiki/BugZappers/HouseKeeping/FourWeeksBeforeRelease"
      }

      task eol_warn_prep "Draft Bugzilla Ticket for EOL Warning" {
        precedes !!!LaunchPhase.ga {gaplength 4w}
        length 0.2d
        flags pm, bugtriage
        note "https://fedoraproject.org/wiki/BugZappers/HouseKeeping/FourWeeksBeforeRelease"
      }

      task web_notes "Post release-notes to fedorahosted.org" {
        depends !build_pr_relnotes
        length 1d
        flags docs
      }

      # what does this task depend on?
      task final_art "Build Final Artwork Package"{
        depends !finalfreeze
        flags art
      }

      # what exactly are these series of tasks and are they still needed?
      # FIXME: be more explicit
      task web "Web Site" {
        depends !finalfreeze
        task web_design "Update Web Site Design" {
          length 15d
          flags art, docs
        }

        task web_proof "Proof and Test Web Site" {
          depends !web_design
          length 5d
          flags art, docs
        }

        task web_launch "Ready for Launch" {
          depends !web_proof
          flags art, docs
        }
      }

      task media "DVD/CD label artwork" {
        depends !finalfreeze
        task design "Design Artwork" {
          length 10d
          flags art
        }

        task prep_printer "Prepare for Printer" {
          depends !design
          length 5d
          flags art
        }

        task print_ready "Ready for Printer" {
          depends !prep_printer
          flags art
        }
      }

      task poster "Release Party Posters" {
        depends !media
        task draft "Initial Drafts" {
          length 2d
          flags art
        }

        task feedback "Mailing List Feedback" {
          depends !draft
          length 2d
          flags art
        }

        task changes "Make Final Changes" {
          depends !feedback
          length 1d
          flags art
        }

        task final "Print Ready Posters" {
          depends !changes
          flags art
        }
      }

      task meeting "Preview Release Meeting" {
        depends !finalfreeze {gaplength 1d}
        milestone
        flags releng, pm, quality, docs, art, report_milestone, translation
      }

      task stage "Compose Stage Sync (releng)" {
        depends !finalfreeze
        length 5d
        flags releng, docs
      }

      task drop "Preview Release Public Availability" {
        milestone
        depends !stage
        flags docs, releng, quality, pm, report_milestone, translation
      }

      task test "Preview Testing" {
        depends !stage
        length 6d
        flags quality
      }

      task testmile "End of Preview Release" {
        milestone
        depends !test
        flags quality, releng, report_milestone
      }
    }
  } # end of TestingPhase

  task LaunchPhase "Launch Phase" {
    task rc "Release Candidate" {

      task prep_notes "Prepare GA Release Notes" {
        depends !!!TestingPhase.pr.drop
        length 1d
        flags docs, quality
      }

      task wiki_port "Port diff wiki content to fh.o/rel-notes" {
        depends !prep_notes
        length 0.5d
        flags docs
      }

      task release_notes_freeze "GA Release Notes String Freeze" {
        depends !wiki_port
        flags docs, report_milestone
      }

      task create_pot "Generate GA Release Notes POT files for Translation" {
        depends !wiki_port
        length 0.5d
        flags docs
      }

      # FIXME: static date--add logic to dynamically select date
      task validate_frn_final_xml "Validate Release Notes Final XML for all languages" {
        start 2008-11-13
        length 1d
        flags docs
      }

      task pot_trans "Translate GA Release Notes (POT to PO)" {
        depends !create_pot    #smoke_pot would not be an appropriate next task ;-)
        length 5d
        flags translation
      }

      task po "Release Notes Translation Deadline" {
        milestone
        depends !pot_trans
        flags translation
      }

      # FIXME: Need preceding tasks for websites team
      # for now just set date manually
      task web_freeze "Website String Freeze" {
        start 2008-11-17
        milestone
        flags web
      }

      task web_pot "Generate Website POT files" {
        start 2008-11-17
        milestone
        flags web
      }

     task trans_web "Translation Period for fedoraproject.org (POT to PO)" {
        depends !web_freeze
        plan: length 4d
        actual: length 5d
        flags translation
      }

     task review_trans_web "Review and correct fedoraproject.org translations" {
        depends !trans_web
        length 1d
        flags translation
      }

      task ig_trans_deadline "Install Guide Translation Deadline" {
        start 2008-11-20
        flags translation
      }

     task finish_trans_web "Web Translation Deadline (PO done for fedoraproject.org)" {
        depends !review_trans_web
        flags translation
      }

     task publish_trans_web "Publish Translations on Website (fedoraproject.org)" {
        depends !review_trans_web
        length 1d
        flags web
      }

      task notes_rpm "Build fedora-release-notes.rpm (FRN)" {
        depends !pot_trans # TODO: check this dependency--I think it might be wrong
        length 0.5d
        flags docs
      }

      task meeting "GA Release Meeting" {
        depends !!!TestingPhase.pr.test {gaplength 5d}
        milestone
        flags releng, pm, quality, docs, art
      }

      task stage "Compose & Red Hat Testing (releng)" {
        depends !!!TestingPhase.pr.test
        length 6d
        flags releng, quality, docs # add docs flag to give visibility that compose is happening which needs FRN.rpm
      }

      task mirror "Post & Sync Mirrors" {
        depends !stage
        length 3d
        flags releng
      }

      task final_beats_snap "Final Wiki Beats Snapshot" {
        depends !notes_rpm {gaplength 5d}
        length 1d
        flags docs
      }

      # FIXME: static date--add logic to dynamically select date
      task validate_ig_final_xml "Validate Install Guide final XML for all languages" {
        start 2008-11-21
        length 1.3d
        flags docs
      }

      task build_ig "Build Install Guide (IG) in all languages" {
        depends !validate_ig_final_xml
        length 0.2d
        flags docs
      }

      task draft_ig_final "Publish Install Guide to web (non-live)" {
        depends !build_ig
        length 0.2d
        flags docs
      }

      task final_wiki_port "Port diff wiki content to fh.o/rel-notes" {
        depends !final_beats_snap
        length 1d
        flags docs
      }

      task zero_day_web "0-Day rel-notes update docs.fp.org" {
        depends !final_wiki_port
        length 0.1d
        flags docs
      }

      task zero_day_rpm "0-Day rel-notes build updated rpm" {
        depends !final_wiki_port
        length 0.1d
        flags docs
      }

      task zero_day_pot "0-Day rel-notes generate POT" {
        depends !final_wiki_port
        length 0.1d
        flags docs
      }

    } # end of rc task


     # two weeks prior to GA prepare tickets for rawhide rebase & EOL warning
      task rebase_ticket "File Bugzilla Ticket for Rawhide Rebase " {
        precedes !!LaunchPhase.ga {gaplength 2w}
        length 0.2d
        flags pm, bugtriage
        note "https://fedoraproject.org/wiki/BugZappers/HouseKeeping/TwoWeeksBeforeRelease"
      }

      task eol_warn_ticket "File Bugzilla Ticket for EOL Warning" {
        precedes !!LaunchPhase.ga {gaplength 2w}
        length 0.2d
        flags pm, bugtriage
        note "https://fedoraproject.org/wiki/BugZappers/HouseKeeping/TwoWeeksBeforeRelease"
      }

      task bugzilla_prep "Draft bugzilla text updates" {
        precedes !!LaunchPhase.ga {gaplength 2w}
        length 0.2d
        flags pm, bugtriage
        note "https://fedoraproject.org/wiki/BugZappers/HouseKeeping/TwoWeeksBeforeRelease"
      }

      task bugzilla "Bugzilla Release Day Preparations" {
        precedes !ga {gaplength 1d}
        length 0.5d
        flags bugtriage, pm
        note "https://fedoraproject.org/wiki/BugZappers/HouseKeeping/DayBeforeRelease"
      }

    # Required for product pages--do not change description
    # TODO: Also make sure to confirm this date with Red Hat IS to
    # make sure it does not conflict with other releases.
    task ga "GA Release" {
      milestone
      flags report_milestone, quality, releng, docs, art, pm, translation
      depends !rc.mirror
    }

    task rawhide_rebase "Bugzilla 'rawhide rebase'" {
      length 0.5d
      flags bugtriage, pm
      depends !ga
    }

    task eol_warn "Apply EOL Warning to all Fedora 8 Bugs " {
      depends !ga {gapduration 1d}
      length 0.5d
      flags bugtriage, pm
    }
  }

  task MaintenancePhase "Maintenance Phase Fedora 10" {

    task updated_trans "Translate 0-day release notes for docs.fp.org" {
      depends  !!LaunchPhase.rc.zero_day_pot {gaplength 1d}
      length 5.5d
      flags translation
    }

    task web_post "Add translated zero-day updates to docs.fp.org" {
      depends !updated_trans
      length 0.5d
      flags docs
    }

    # FIXME: where should the tasks for ending maintenance of Fedora 8 live?
    #  consider adding to end of F8 schedule OR putting as tasks to complete during F11?
    task eolwarning "Send F10 EOL Warning to mailing lists" {
      depends !!LaunchPhase.ga {gapduration 364d}
      length 0.5d
      flags bugtriage, releng, pm
    }

    task orphanwarn "Send out list of orphaned packages to mailing lists" {
      depends !eolwarning
      length 0.1d
      flags releng, pm
    }

    task eolbugzilla "Automatically close all open bugs for F10" {
      depends !eolwarning {gapduration 28d}
      length 0.1d
      flags bugtriage, releng, pm
    }

   task block "Block (stop) Fedora 10 updates" {
      depends !eolwarning {gapduration 28d}
      length 0.1d
      flags releng, pm
    }

    task orphan "Remove orphaned packages" {
      depends !orphanwarn {gapduration 28d}
      length 0.1d
      flags releng
    }
  }

} # Bitter End


